# WBS G1

Schedule from MS Project, 2013-01-07 to 2016-04-15.

## Calendars

- Standard: Mon-Fri 08:00-12:00, 13:00-17:00; Sat-Sun off. Exceptions (off unless hours are given): 2013-08-08 to 2013-08-09 (Raya Puasa), 2013-09-02 (Merdeka), 2013-09-16 (Hari Malaysia), 2013-10-15 to 2013-10-16 (Hari Raya Haji), 2013-11-05 (Maal Hijrah), 2013-11-25 (Krismas), 2014-01-01 (New year), 2014-01-14 (Maulud Nabi), 2014-01-24 (Thaipusam), 2014-01-31 (CNY), 2014-05-01 (Hari Pekerja), 2014-05-14 (Wesak), 2014-07-29 to 2014-07-30 (HR Aidilfitri), 2014-09-01 (Merdeka), 2014-09-16 (Hari Malaysia), 2014-10-05 to 2014-10-06 (HR Qurban), 2014-10-23 (Deepavali), 2014-12-25 (Krismas), 2015-01-01 (New Year), 2015-02-01 to 2015-02-02 (Hari Wilayah), 2015-02-19 to 2015-02-20 (CNY), 2015-02-24 (Thaipusam), 2015-05-01 (Hari Pekerja), 2015-05-14 (Wesak), 2015-07-18 to 2015-07-20 (HR Aidilfitri), 2015-08-31 (Merdeka), 2015-09-16 (Hari Malaysia), 2015-09-24 (HR Qurban), 2015-10-15 (Awal Muharram).

## Schedule

| ID | WBS | Task | Type | Duration | Start | Finish | Predecessors | Total slack | Free slack |
| --- | --- | --- | --- | --- | --- | --- | --- | --- | --- |
| 1 | 1 | **PROJEK MAHKAMAH BARU KOTA KINABALU, SABAH** |  | 822d | 2013-01-07 | 2016-04-15 |  | 0d |  |
| 2 | 1.1 | Start | milestone | 0d | 2013-01-07 | 2013-01-07 |  | 822d |  |
| 3 | 1.2 | **Perancangan** |  | 107d | 2013-01-07 | 2013-06-04 |  | 659d |  |
| 4 | 1.2.1 | Pelantikan HODT Elektrik oleh HOPT |  | 1d | 2013-01-07 | 2013-01-07 |  | 659d | 0d |
| 5 | 1.2.2 | Penetapan HODT oleh PPR |  | 1d | 2013-01-08 | 2013-01-08 | 4 | 659d | 0d |
| 6 | 1.2.3 | Maklumat pasukan rekabentuk HODT Elektrik kepada HOPT |  | 1d | 2013-01-09 | 2013-01-09 | 5 | 659d | 0d |
| 7 | 1.2.4 | Menghadiri mesyuarat koordinasi HODT bersama HOPT |  | 1d | 2013-01-10 | 2013-01-10 | 6 | 659d | 0d |
| 8 | 1.2.5 | Penerimaan brief projek |  | 1d | 2013-01-11 | 2013-01-11 | 7 | 659d | 0d |
| 9 | 1.2.6 | Mesyuarat Koordinasi Bil.1 |  | 1d | 2013-01-14 | 2013-01-14 | 8 | 659d | 0d |
| 10 | 1.2.7 | Penyediaan Pelan Kualiti Rekabentuk (D-Plan) |  | 1d | 2013-01-14 | 2013-01-14 | 9SS | 659d | 0d |
| 11 | 1.2.8 | Lawatan Tapak |  | 1d | 2013-01-29 | 2013-01-29 | 10FS+10d | 659d | 0d |
| 12 | 1.2.9 | Verifikasi harta pelanggan |  | 1d | 2013-01-29 | 2013-01-29 | 10FS+10d | 802d | 0d |
| 13 | 1.2.10 | Pengesahan brief dan skop projek oleh pelanggan |  | 1d | 2013-01-30 | 2013-01-30 | 12 | 802d | 0d |
| 14 | 1.2.11 | Mesyuarat skop kerja elektrik dengan pelanggan |  | 1d | 2013-01-31 | 2013-01-31 | 13 | 802d | 0d |
| 15 | 1.2.12 | Pengesahan skop elektrik dengan pelanggan |  | 1d | 2013-01-31 | 2013-01-31 | 14SS | 802d | 0d |
| 16 | 1.2.13 | Menyediakan anggaran kos projek |  | 1d | 2013-02-01 | 2013-02-01 | 15 | 802d |  |
| 17 | 1.2.14 | **Pelantikan Perunding** |  | 91d | 2013-01-29 | 2013-06-04 |  | 659d |  |
| 18 | 1.2.14.1 | Penyediaan Dokumen Pengesyoran Nama Perunding ,Kos & TOR kepada JPP |  | 15d | 2013-01-29 | 2013-02-18 | 11SS | 659d | 0d |
| 19 | 1.2.14.2 | Kelulusan JPP CKE |  | 1d | 2013-02-19 | 2013-02-19 | 18 | 659d | 0d |
| 20 | 1.2.14.3 | Penyediaan Dokumen Tender Perunding |  | 5d | 2013-02-20 | 2013-02-26 | 19 | 659d | 0d |
| 21 | 1.2.14.4 | Penyerahan Dokumen Tawaran Kepada Perunding Disenarai-pendek |  | 10d | 2013-02-27 | 2013-03-12 | 20 | 659d | 0d |
| 22 | 1.2.14.5 | Tutup Tender |  | 1d | 2013-03-13 | 2013-03-13 | 21 | 659d | 0d |
| 23 | 1.2.14.6 | Penilaian Tender |  | 10d | 2013-03-14 | 2013-03-27 | 22 | 659d | 0d |
| 24 | 1.2.14.7 | Kelulusan JPP CKE |  | 1d | 2013-04-04 | 2013-04-04 | 23FS+5d | 659d | 0d |
| 25 | 1.2.14.8 | Kelulusan PBM |  | 1d | 2013-04-19 | 2013-04-19 | 24FS+10d | 659d | 0d |
| 26 | 1.2.14.9 | Keluar Surat Setuju Terima |  | 5d | 2013-04-22 | 2013-04-26 | 25 | 659d | 0d |
| 27 | 1.2.14.10 | Mesyuarat Pra-Rekabentuk dengan Perunding Elektrik |  | 1d | 2013-04-29 | 2013-04-29 | 26 | 715d | 0d |
| 28 | 1.2.14.11 | Penyediaan Memorandum of Agreement (MOA) |  | 15d | 2013-04-30 | 2013-05-20 | 27 | 715d | 0d |
| 29 | 1.2.14.12 | Tandatangan MOA |  | 1d | 2013-05-24 | 2013-05-24 | 28FS+3d | 715d | 0d |
| 30 | 1.2.14.13 | Penjilidan dan Edaran MOA |  | 5d | 2013-05-29 | 2013-06-04 | 29FS+2d | 715d |  |

| ID | WBS | Task | Duration | Start | Finish | Predecessors | Total slack | Free slack | Constraint |
| --- | --- | --- | --- | --- | --- | --- | --- | --- | --- |
| 31 | 1.3 | **Rekabentuk** | 85d | 2013-04-30 | 2013-08-28 |  | 630d |  |  |
| 32 | 1.3.1 | **Mesyuarat Koordinasi Rekabentuk** | 31d | 2013-04-30 | 2013-06-11 |  | 710d |  |  |
| 33 | 1.3.1.1 | Mesyuarat Koordinasi Rekabentuk 1 | 1d | 2013-04-30 | 2013-04-30 |  | 740d |  | start no earlier than 2013-04-30 |
| 34 | 1.3.1.2 | Mesyuarat Koordinasi Rekabentuk 2 | 1d | 2013-05-14 | 2013-05-14 |  | 730d |  | start no earlier than 2013-05-14 |
| 35 | 1.3.1.3 | Mesyuarat Koordinasi Rekabentuk 3 | 1d | 2013-05-28 | 2013-05-28 |  | 720d |  | start no earlier than 2013-05-28 |
| 36 | 1.3.1.4 | Mesyuarat Koordinasi Rekabentuk 4 | 1d | 2013-06-11 | 2013-06-11 |  | 710d |  | start no earlier than 2013-06-11 |
| 37 | 1.3.2 | Penerimaan Lukisan awalan Senibina/Geometrik | 1d | 2013-05-13 | 2013-05-13 | 26FS+10d | 659d | 0d |  |
| 38 | 1.3.3 | **Rekabentuk Awalan** | 51d | 2013-05-14 | 2013-07-23 |  | 659d |  |  |
| 39 | 1.3.3.1 | Penyediaan Rekabentuk Konsep Elektrik / Awalan (space/scope/SOA requirement) | 10d | 2013-05-14 | 2013-05-27 | 37 | 659d | 0d |  |
| 40 | 1.3.3.2 | Mesyuarat Rekabentuk Awalan/Konsep | 1d | 2013-05-28 | 2013-05-28 | 39 | 659d | 0d |  |
| 41 | 1.3.3.3 | Permohonan Dan Maklumbalas Beban Mekanikal Drpd HODT Mekanikal | 20d | 2013-05-14 | 2013-06-10 | 39SS | 681d | 22d |  |
| 42 | 1.3.3.4 | Permohonan Dan Kelulusan Bekalan Elektrik Kepada TNB/SESCO/SESB | 40d | 2013-05-28 | 2013-07-22 | 40SS | 681d |  |  |
| 43 | 1.3.3.5 | Permohonan dan Kelulusan Infrastruktur Telefon Kepada TM/TELCO | 40d | 2013-05-29 | 2013-07-23 | 40 | 680d |  |  |
| 44 | 1.3.3.6 | Penerimaan Lukisan Akhir Senibina/Geometrik | 1d | 2013-07-10 | 2013-07-10 | 40FS+30d | 659d | 0d |  |
| 45 | 1.3.4 | **Penyediaan Rekabentuk Terperinci** | 30d | 2013-07-11 | 2013-08-23 |  | 578d |  |  |
| 46 | 1.3.4.1 | **Penyediaan Lukisan Susunatur** | 20d | 2013-07-11 | 2013-08-07 |  | 659d |  |  |
| 47 | 1.3.4.1.1 | Elektrik | 20d | 2013-07-11 | 2013-08-07 | 44, 41 | 659d | 0d |  |
| 48 | 1.3.4.1.2 | ELV | 20d | 2013-07-11 | 2013-08-07 | 44 | 659d | 0d |  |
| 49 | 1.3.4.1.3 | ICT | 20d | 2013-07-11 | 2013-08-07 | 44 | 659d | 0d |  |
| 50 | 1.3.4.2 | Lukisan Koordinasi IBS Elektrik | 5d | 2013-08-12 | 2013-08-16 | 47, 48, 49 | 664d |  |  |
| 51 | 1.3.4.3 | **Penyediaan Lukisan Skematik** | 10d | 2013-08-12 | 2013-08-23 |  | 659d |  |  |
| 52 | 1.3.4.3.1 | Elektrik | 10d | 2013-08-12 | 2013-08-23 | 47 | 659d |  |  |
| 53 | 1.3.4.3.2 | ELV | 10d | 2013-08-12 | 2013-08-23 | 48 | 659d |  |  |
| 54 | 1.3.4.3.3 | ICT | 10d | 2013-08-12 | 2013-08-23 | 49 | 659d |  |  |

Notes:
- 39: Terima SOA terperinci daripada Arkitek
- 44: Lukisan 1: 100 scale

| ID | WBS | Task | Type | Duration | Start | Finish | Predecessors | Total slack | Free slack | Constraint |
| --- | --- | --- | --- | --- | --- | --- | --- | --- | --- | --- |
| 55 | 1.3.4.4 | **Kajian Semula Lukisan Rekabentuk** |  | 9d | 2013-07-30 | 2013-08-13 |  | 557d | 0d |  |
| 56 | 1.3.4.4.1 | Kajian Semula Lukisan Rekabentuk 1 |  | 1d | 2013-07-30 | 2013-07-30 |  | 565d |  | start no earlier than 2013-07-30 |
| 57 | 1.3.4.4.2 | Kajian Semula Lukisan Rekabentuk 2 |  | 1d | 2013-08-06 | 2013-08-06 |  | 560d |  | start no earlier than 2013-08-06 |
| 58 | 1.3.4.4.3 | Kajian Semula Lukisan Rekabentuk 3 |  | 1d | 2013-08-13 | 2013-08-13 |  | 557d |  | start no earlier than 2013-08-13 |
| 59 | 1.3.4.5 | **Verifikasi rekabentuk** |  | 1d | 2013-08-14 | 2013-08-14 | 55 | 557d |  |  |
| 60 | 1.3.4.5.1 | Elektrik |  | 1d | 2013-08-14 | 2013-08-14 | 55 | 557d | 0d |  |
| 61 | 1.3.4.5.2 | ELV |  | 1d | 2013-08-14 | 2013-08-14 | 55 | 557d | 0d |  |
| 62 | 1.3.4.5.3 | ICT |  | 1d | 2013-08-14 | 2013-08-14 | 55 | 557d | 0d |  |
| 63 | 1.3.5 | **Penyediaan BQ Dan Spesifikasi** |  | 10d | 2013-08-15 | 2013-08-28 |  | 557d | 0d |  |
| 64 | 1.3.5.1 | Elektrik |  | 10d | 2013-08-15 | 2013-08-28 | 60 | 557d | 0d |  |
| 65 | 1.3.5.2 | ELV |  | 10d | 2013-08-15 | 2013-08-28 | 61 | 557d | 0d |  |
| 66 | 1.3.5.3 | ICT |  | 10d | 2013-08-15 | 2013-08-28 | 62 | 557d | 0d |  |
| 67 | 1.4 | **Perolehan** |  | 99d | 2013-08-29 | 2014-01-27 |  | 557d |  |  |
| 68 | 1.4.1 | Penyediaan Dokumen Meja Tender |  | 5d | 2013-08-29 | 2013-09-05 | 64, 65, 66 | 651d |  |  |
| 69 | 1.4.2 | Mohon dan terima LO daripada HOPT |  | 14d | 2013-08-29 | 2013-09-19 | 63 | 557d | 0d |  |
| 70 | 1.4.3 | **Tender** |  | 17d | 2013-09-19 | 2013-10-11 |  | 557d |  |  |
| 71 | 1.4.3.1 | Iklan Tender |  | 1d | 2013-09-19 | 2013-09-19 | 69FS-1d | 557d | 0d |  |
| 72 | 1.4.3.2 | Jual Tender |  | 10d | 2013-09-20 | 2013-10-03 | 71 | 557d | 0d |  |
| 73 | 1.4.3.3 | Tutup Tender |  | 1d | 2013-10-11 | 2013-10-11 | 72FS+5d | 557d | 0d |  |
| 74 | 1.4.4 | **Penilaian Tender** |  | 16d | 2013-10-23 | 2013-11-14 |  | 557d |  |  |
| 75 | 1.4.4.1 | Penerimaan Dokumen Tender |  | 1d | 2013-10-23 | 2013-10-23 | 73FS+5d | 557d | 0d |  |
| 76 | 1.4.4.2 | Penyediaan Laporan Penilaian Tender |  | 15d | 2013-10-24 | 2013-11-14 | 75 | 557d | 0d |  |
| 77 | 1.4.4.3 | Kelulusan Lembaga Perolehan | milestone | 0d | 2013-11-14 | 2013-11-14 | 76 | 557d | 0d |  |
| 78 | 1.4.5 | **Penyediaan dan Penyerahan Dokumen Sub-Kontrak** |  | 48d | 2013-11-15 | 2014-01-27 |  | 557d |  |  |
| 79 | 1.4.5.1 | Penyediaan SST dan Borang Kontrak untuk ditandatangani oleh SO |  | 5d | 2013-11-15 | 2013-11-21 | 77 | 557d | 0d |  |
| 80 | 1.4.5.2 | Penerimaan Borang Kontrak |  | 1d | 2013-12-23 | 2013-12-23 | 79FS+20d | 557d | 0d |  |
| 81 | 1.4.5.3 | Kompilasi dokumen sub-kontrak |  | 10d | 2013-12-24 | 2014-01-07 | 80 | 557d | 0d |  |
| 82 | 1.4.5.4 | Menjilid dokumen sub-kontrak |  | 10d | 2014-01-08 | 2014-01-22 | 81 | 557d | 0d |  |
| 83 | 1.4.5.5 | Mengedar dokumen sub-kontrak |  | 2d | 2014-01-23 | 2014-01-27 | 82 | 557d |  |  |

| ID | WBS | Task | Type | Duration | Start | Finish | Predecessors | Total slack | Constraint |
| --- | --- | --- | --- | --- | --- | --- | --- | --- | --- |
| 84 | 1.5 | **Pembinaan** |  | 502d | 2013-12-09 | 2015-12-15 |  | 88d |  |
| 85 | 1.5.1 | Mesyuarat Penyerahan Projek untuk Penyeliaan |  | 1d | 2013-12-09 | 2013-12-09 | 79FS+10d | 589d |  |
| 86 | 1.5.2 | **Audit Pembinaan oleh HODT** |  | 497d | 2013-12-16 | 2015-12-15 |  | 88d |  |
| 87 | 1.5.2.1 | Audit Pembinaan oleh HODT 1 |  | 1d | 2013-12-16 | 2013-12-16 |  | 584d | start no earlier than 2013-12-15 |
| 88 | 1.5.2.2 | Audit Pembinaan oleh HODT 2 |  | 1d | 2014-04-15 | 2014-04-15 |  | 502d | start no earlier than 2014-04-15 |
| 89 | 1.5.2.3 | Audit Pembinaan oleh HODT 3 |  | 1d | 2014-08-15 | 2014-08-15 |  | 418d | start no earlier than 2014-08-15 |
| 90 | 1.5.2.4 | Audit Pembinaan oleh HODT 4 |  | 1d | 2014-12-15 | 2014-12-15 |  | 336d | start no earlier than 2014-12-15 |
| 91 | 1.5.2.5 | Audit Pembinaan oleh HODT 5 |  | 1d | 2015-04-15 | 2015-04-15 |  | 255d | start no earlier than 2015-04-15 |
| 92 | 1.5.2.6 | Audit Pembinaan oleh HODT 6 |  | 1d | 2015-08-17 | 2015-08-17 |  | 170d | start no earlier than 2015-08-15 |
| 93 | 1.5.2.7 | Audit Pembinaan oleh HODT 7 |  | 1d | 2015-12-15 | 2015-12-15 |  | 0d | start no earlier than 2015-12-15 |
| 94 | 1.6 | **Penyerahan** |  | 822d | 2013-01-07 | 2016-04-15 |  | 0d |  |
| 95 | 1.6.1 | Audit Pra Penyerahan (Unit Senggara) |  | 1d | 2016-01-27 | 2016-01-27 | 93FS+30d | 0d |  |
| 96 | 1.6.2 | Pengujian dan Pentauliahan |  | 40d | 2016-01-28 | 2016-03-23 | 95 | 0d |  |
| 97 | 1.6.3 | Penyerahan |  | 1d | 2016-04-15 | 2016-04-15 | 96FS+16d | 0d |  |
| 98 | 1.6.4 | Tempoh Tanggungan Kecacatan |  | 331d | 2013-01-07 | 2014-04-30 |  | 491d |  |
| 99 | 1.6.5 | Finish | milestone | 0d | 2016-04-15 | 2016-04-15 | 97 | 0d |  |
